# Stage-1-Project-Plan

Schedule from MS Project, 2014-01-01 to 2015-10-19.

## Calendars

- Standard: Mon-Fri 08:00-12:00, 13:00-17:00; Sat-Sun off. Exceptions (off unless hours are given): 2014-12-20 08:00-12:00, 13:00-17:00.

## Resources

| Resource |
| --- |
| Guo |
| Svetek |
| Klabbers |
| Cali |
| Iles |
| Gorski |
| Da Silva |
| Zabi |
| Anatoli |
| Marcelo |
| LLR-Tech-1 |
| LLR-Tech-2 |
| Yannick |
| Thierry |
| UW Student 1 |
| Thea |
| Firmware Enginner 1 |
| Firmware Engineer 2 |
| Rice PostDoc |
| FNAL PostDoc |
| GM Innocenti |
| M Guilbaud |
| Newbold |
| Dasgupta |
| BU |
| Tapper |
| Brooke |
| T. Durkin |
| A Rose |
| A Bundock |
| J Marrouche |
| J Baptist |
| K. Harder |
| Jeitler |
| S Harper |
| Luca Mastrolorenzo |
| Florian |
| Matias |
| D Newbold |
| A. Barbieri |
| M. Northrup |
| E. Laird |

## Schedule

| ID | WBS | Task | Type | Duration | Start | Finish | Predecessors | Total slack | Free slack | Constraint | Resources | Work |
| --- | --- | --- | --- | --- | --- | --- | --- | --- | --- | --- | --- | --- |
| 1 | 1 | **Stage-1-Project-Plan** |  | 470d? | 2014-01-01 | 2015-10-19 |  | 0d |  |  |  | 35188.3h |
| 2 | 1.1 | Preliminary Patch Panel Installation at 904 |  | 1w | 2014-03-17 | 2014-03-21 |  | 112d | 0d | start no earlier than 2014-03-17 | T. Durkin | 40h |
| 3 | 1.2 | Preliminary System tests Layer-1/Layer-2 using MP7s at 904 |  | 2w | 2014-03-24 | 2014-04-04 | 2 | 112d | 0d | start no earlier than 2014-03-24 | Tapper; Iles; T. Durkin; Newbold; A Rose; Thea [50%] | 440h |
| 4 | 1.3 | MP7 Production + 2 MP7s |  | 1mo | 2014-04-01 | 2014-04-28 |  | 203d | 0d | start no earlier than 2014-04-01 | Iles [15%] | 24h |
| 5 | 1.4 | MP7 Testing firmware (MP7-suite) |  | 1mo | 2014-04-01 | 2014-04-28 |  | 219d | 0d | start no earlier than 2014-04-01 | A Bundock | 160h |
| 6 | 1.5 | MP7 Production + 4 MP7s and testing |  | 5w | 2014-04-29 | 2014-06-02 | 4, 5 | 203d | 0d |  | Iles [15%]; T. Durkin [20%] | 70h |
| 7 | 1.6 | MP7 Production + 10 MP7s and testing |  | 6w | 2014-06-03 | 2014-07-14 | 6 | 151d | 0d |  | Iles [15%]; A Bundock [20%] | 84h |
| 8 | 1.7 | Second MP7 production line for another 16 MP7s |  | 13w | 2014-05-01 | 2014-07-30 |  | 276d | 0d | start no earlier than 2014-05-01 | Iles [15%]; A Bundock [20%] | 182h |
| 9 | 1.8 | MP7 Production complete - 32 MP7 Cards available for use | milestone | 1d? | 2014-07-31 | 2014-07-31 | 8, 7 | 41d | 17d |  |  |  |
| 10 | 1.9 | P5 DAQ DAQ1--> DAQ2 --- DAQ GROUP |  | 31d? | 2014-04-14 | 2014-05-26 |  | 288d | 0d | start no earlier than 2014-04-14 |  |  |
| 11 | 1.10 | P5 DAQ2 Commissioning --- DAQ GROUP |  | 26d? | 2014-05-27 | 2014-07-01 | 10 | 54d | 0d | start no earlier than 2014-05-27 |  |  |
| 12 | 1.11 | MP7 DAQ Interface Firmware |  | 2mo | 2014-04-01 | 2014-05-26 |  | 157d | 5d | start no earlier than 2014-04-01 | Newbold [25%]; Dasgupta [50%] | 240h |
| 13 | 1.12 | Assemblying DAQ testsetup, FEDkit, MiniDAQ at 904 |  | 12w | 2014-04-01 | 2014-06-23 |  | 157d | 6d | start no earlier than 2014-04-01 | K. Harder | 480h |
| 14 | 1.13 | Final Version AMC13 Arrives at CERN | milestone | 1d? | 2014-06-02 | 2014-06-02 |  | 107d | 0d | start no earlier than 2014-06-02 |  |  |
| 15 | 1.14 | Integration MP7-DAQ interface with AMC13 |  | 4w | 2014-06-03 | 2014-06-30 | 14, 12 | 158d | 1d |  | Dasgupta; BU | 320h |
| 16 | 1.15 | Integration with DAQ2/XDAQ and testing |  | 4w | 2014-07-02 | 2014-07-29 | 15, 13, 11 | 157d | 0d |  | Thea; K. Harder | 320h |
| 17 | 1.16 | MP7 Data unpacker |  | 1mo | 2014-04-01 | 2014-04-28 |  | 354d | 66d | start no earlier than 2014-04-01 | Tapper; Brooke | 320h |
| 18 | 1.17 | MP7 - DAQ Interface and Data unpacking ready | milestone | 1d | 2014-07-30 | 2014-07-30 | 17, 16 | 54d | 22d |  |  |  |
| 19 | 1.18 | Firmware for MP7->Legacy GT-oGTI 3 GBps Intrface |  | 6w | 2014-04-07 | 2014-05-16 | 3 | 157d | 30d |  | Iles | 240h |
| 20 | 1.19 | DEMUX Firmware |  | 3mo | 2014-04-07 | 2014-06-27 |  | 98d | 0d | start no earlier than 2014-04-07 | D Newbold | 480h |
| 21 | 1.20 | Installation and PC connection of the two Layer-2 uTCA MP7 Crates at P5 |  | 2w | 2014-06-16 | 2014-06-27 | 14 | 127d | 0d | start no earlier than 2014-06-16 | Iles [50%]; Thea [50%] | 80h |
| 22 | 1.21 | Integration of MP7 3 GBPs links with Legacy GT/oGTI |  | 1w | 2014-06-30 | 2014-07-04 | 21, 20, 19 | 127d | 0d |  | Iles; Jeitler | 80h |
| 23 | 1.22 | Interface of 2016 Trigger Layer-2 MP7 to Legacy GT oGTI Complete | milestone | 1d? | 2014-07-07 | 2014-07-07 | 22 | 54d | 10d |  |  |  |
| 24 | 1.23 | Installation of the 12 Layer-2 MP7s at the two crates at P5 |  | 1w | 2014-07-15 | 2014-07-21 | 7 | 194d | 0d |  | T. Durkin | 40h |
| 25 | 1.24 | 2016 Trigger Layer-2 12 MP7s installed in 2 crates at P5 | milestone | 1d? | 2014-07-22 | 2014-07-22 | 24 | 94d | 50d |  |  |  |
| 26 | 1.25 | First Version of the CMSSW Electron finder |  | 1mo | 2014-03-17 | 2014-04-11 |  | 155d | 0d | start no earlier than 2014-03-17 | J Baptist; S Harper; Tapper [20%] | 352h |
| 27 | 1.26 | First Version of the CMSSW Tau Algorithm |  | 8w | 2014-03-17 | 2014-05-09 |  | 156d | 102d | start no earlier than 2014-03-17 | Luca Mastrolorenzo; Florian | 640h |
| 28 | 1.27 | First version of the CMSSW Jet/MET/MHT/Ht/Et triggers WITH PU sub. |  | 2mo | 2014-03-17 | 2014-05-09 |  | 196d | 102d | start no earlier than 2014-03-17 | J Marrouche [50%]; Brooke | 480h |
| 29 | 1.28 | First Version Firmware of 2016 Trigger Electron Finder |  | 7w | 2014-03-17 | 2014-05-02 |  | 150d | 0d | start no earlier than 2014-03-17 | A Rose [50%]; Thierry | 420h |
| 30 | 1.29 | First Version Firmware of the 2016 Trigger Tau finder |  | 1mo | 2014-05-05 | 2014-05-30 | 29 | 180d | 30d |  | A Rose [50%]; Thierry | 240h |
| 31 | 1.30 | First Version of Jet/MET/MHT/Et/Ht Triggers with no PU |  | 4w | 2014-03-17 | 2014-04-11 |  | 115d | 0d | start no earlier than 2014-03-17 | A Rose [50%] | 80h |
| 32 | 1.31 | Pattern Testing of Jet/MET/MHT/Et/Ht Triggers woth no PU |  | 6w | 2014-04-14 | 2014-05-23 | 31, 26 | 155d | 0d |  | A Rose [50%] | 120h |
| 33 | 1.32 | First Version Firmware for the 2016 Jet/MET/MHT/Et/Ht Triggers + PU |  | 6w | 2014-05-26 | 2014-07-04 | 32 | 155d | 5d |  | A Rose | 240h |
| 34 | 1.33 | Pattern Tests for Commissioning Electron and tau Algorithms 904 |  | 1mo | 2014-05-05 | 2014-05-30 | 26, 29 | 150d | 0d |  | Thierry; Zabi [25%]; A Bundock | 360h |
| 35 | 1.34 | Pattern Tests for Commissionng Jet/MHT/MET/Et/Ht Triggers + PU 904 |  | 6w | 2014-06-02 | 2014-07-11 | 34 | 150d | 0d |  | A Bundock; J Marrouche [50%] | 360h |
| 36 | 1.35 | Development of Version 1 of Layer 2 Algorithm Firmware Complete | milestone | 1d? | 2014-07-14 | 2014-07-14 | 35, 33, 30 | 100d | 56d |  |  |  |
| 37 | 1.36 | CTP7 Prototype testing |  | 12w | 2014-04-01 | 2014-06-23 |  | 68d | 0d | start no earlier than 2014-04-01 | Gorski | 480h |
| 38 | 1.37 | CTP7 Pre-Production of 6 CTP7s 4 of which are for CERN |  | 1mo | 2014-06-24 | 2014-07-21 | 37 | 68d | 0d |  | Gorski [15%] | 24h |
| 39 | 1.38 | CTP7 Pre-Production testing |  | 1mo | 2014-07-22 | 2014-08-18 | 38 | 68d | 0d |  | Gorski | 160h |
| 40 | 1.39 | Final CTP7 production |  | 9w | 2014-10-01 | 2014-12-02 | 39 | 88d | 0d | start no earlier than 2014-10-01 |  |  |
| 41 | 1.40 | Final CTP7 Production testing of 4 CTP7s |  | 4w | 2014-12-03 | 2014-12-29 | 40 | 87d | 0d |  | Gorski; Guo | 320h |
| 42 | 1.41 | Shipping 3-4 Pre-production CTP7s to CERN |  | 49d | 2014-08-19 | 2014-10-24 | 39 | 10d | 0d |  |  |  |
| 43 | 1.42 | 4 Pre-Production CTP7s at CERN | milestone | 1d? | 2014-10-27 | 2014-10-27 | 42 | 10d | 0d |  |  |  |
| 44 | 1.43 | Shipping 1st set of 4 production CTP7s to CERN |  | 3w | 2014-12-30 | 2015-01-19 | 41 | 77d | 0d |  |  |  |
| 45 | 1.44 | 8 CTP7s at CERN ready for installation | milestone | 1d? | 2015-01-20 | 2015-01-20 | 44 | 77d | 0d |  |  |  |
| 46 | 1.45 | Testing the 2nd set of 4 production CTP7s |  | 3w | 2014-12-30 | 2015-01-19 | 41 | 88d | 0d |  | Gorski [50%]; Guo [50%] | 120h |
| 47 | 1.46 | Shipping the 2nd set of 4 production CTP7s to CERN |  | 1w | 2015-01-20 | 2015-01-26 | 46 | 98d | 0d |  |  |  |
| 48 | 1.47 | All 12 working CTP7s at CERN (4 PreProduction + 8 Production) | milestone | 1d? | 2015-01-27 | 2015-01-27 | 47 | 98d | 29d |  |  |  |
| 49 | 1.48 | Testing of the 3d set of 8 Production CTP7 |  | 1mo | 2015-01-20 | 2015-02-16 | 46 | 88d | 0d |  | Gorski [50%]; Guo [50%] | 160h |
| 50 | 1.49 | Shipping of 8 CTP7 to CERN |  | 1w | 2015-02-17 | 2015-02-23 | 49 | 170d |  |  |  |  |
| 51 | 1.50 | Testing of next 8 Production CTP7s |  | 1mo | 2015-02-17 | 2015-03-16 | 49 | 88d | 0d |  | Gorski [50%]; Guo [50%] | 160h |
| 52 | 1.51 | Shipping 8 Production CTP7 to CERN |  | 1w | 2015-03-17 | 2015-03-23 | 51 | 88d | 0d |  |  |  |
| 53 | 1.52 | 28 CTP7s at CERN | milestone | 1d? | 2015-03-24 | 2015-03-24 | 52 | 88d | 19d |  |  |  |
| 54 | 1.53 | Testing 4 Production CTP7 |  | 2w | 2015-03-17 | 2015-03-30 | 51 | 98d | 0d |  | Gorski | 80h |
| 55 | 1.54 | Shipping 4 production CTP7s to CERN |  | 1w | 2015-03-31 | 2015-04-06 | 54 | 98d | 0d |  |  |  |
| 56 | 1.55 | 36 CTP7s Available at CERN for Completing the 2016 Trigger | milestone | 1d? | 2015-04-07 | 2015-04-07 | 55 | 98d | 29d |  |  |  |
| 57 | 1.56 | CTP7 Service fiirmware+ Data pass-through - CTP7 at CERN 904 is required from 1.4.2014 |  | 4mo | 2014-04-01 | 2014-07-21 |  | 117d | 0d | start no earlier than 2014-04-01 | Svetek | 640h |
| 58 | 1.57 | oSLB/uHTR-->CTP7-->MP7-->GT SLICE TEST TDR MILESTONE + DAQ at P5 |  | 2w | 2014-07-22 | 2014-08-04 | 23, 57 | 88d | 0d |  | Iles; Da Silva; A Rose; Gorski; Jeitler; Thea; Svetek; T. Durkin | 640h |
| 59 | 1.58 | Slice Test oSLB/oRM--CTP7-->MP7->GT Milestone Completed | milestone | 1d? | 2014-08-05 | 2014-08-05 | 58 | 50d | 0d |  |  |  |
| 60 | 1.59 | Firmware CTP7 Layer-1 TMT Version 1 - Basic Input play back + TMT FW |  | 4mo | 2014-08-06 | 2014-11-25 | 59 | 72d | 0d |  | Svetek | 640h |
| 61 | 1.60 | Firmware CTP7 Layer-1 TMT Version 2 - Including full Pattern, TMT and test functionality |  | 2mo | 2014-11-26 | 2015-01-19 | 60 | 72d | 0d |  | Svetek [50%] | 160h |
| 62 | 1.61 | Layer-1 Firmware Development Complete without DAQ Link | milestone | 1d? | 2015-01-20 | 2015-01-20 | 61 | 77d | 19d |  |  |  |
| 63 | 1.62 | Firmware for testing the Patch Panel connections using MP7 |  | 2mo | 2014-04-07 | 2014-05-30 | 3 | 320d | 116d |  | A Bundock | 320h |
| 64 | 1.63 | Layer-1 - Layer -2 Patch Panel manufacture |  | 12w | 2014-04-07 | 2014-06-27 | 3 | 241d | 0d |  | T. Durkin [15%] | 72h |
| 65 | 1.64 | Layer-1 - Layer -2 Patch-Panel precabling at RAL |  | 4w | 2014-06-30 | 2014-07-25 | 64 | 241d | 0d |  | T. Durkin | 160h |
| 66 | 1.65 | Layer-1 - Layer-2 Patch Panel shipping from RAL to P5 |  | 1w | 2014-07-28 | 2014-08-01 | 65 | 241d | 0d |  |  |  |
| 67 | 1.66 | Layer-1 - Layer-2 Patch Panel installation at CERN |  | 1w | 2014-08-04 | 2014-08-08 | 66 | 241d | 56d |  | T. Durkin | 40h |
| 68 | 1.67 | oSLB/uHTR Patch Panel Design |  | 1mo | 2014-04-01 | 2014-04-28 |  | 220d | 0d | start no earlier than 2014-04-01 |  |  |
| 69 | 1.68 | oSLB/uHTR Patch Panel manufacture and procurement |  | 12w | 2014-04-29 | 2014-07-21 | 68 | 250d | 0d |  |  |  |
| 70 | 1.69 | oSLB/oRM Patch Panel Transport to CERN |  | 1w | 2014-07-22 | 2014-07-28 | 69 | 250d | 65d |  |  |  |

Notes:
- 15: 11.3.2014 Dave Newbold / Hi, / There are several components, and some are not in our hands. I would say / the following is the task list, where the time estimates include test / and debug. They are basically sequential, i.e. one cannot be done with / the previous ones. / - MP7 firmware - 1 month [Dasgupta, Newbold] / - AMC13 interface - 1 month [BU, Dasgupta] / - Integration with DAQ2 / XDAQ and test - 1 month [Harder, Thea] / - Unpackers, integration with CMSSW - 1 month [Tapper, Brooke] / This sounds bad, but note that these tasks overlap 100% with the work / required for other Stage-2 boards, i.e. *every* component can be the / same for MP7, CTP7, MTF7 in principle. This would require some / agreement, however. / Note that the AMC13 interface and integration with DAQ are stalled right / now waiting on other people. / Also note that *all* these tasks are also required for Stage-1, or we / cannot read out either the MP7 or CTP7. / Dave
- 16: 11.3.2014 Dave Newbold / Hi, / There are several components, and some are not in our hands. I would say / the following is the task list, where the time estimates include test / and debug. They are basically sequential, i.e. one cannot be done with / the previous ones. / - MP7 firmware - 1 month [Dasgupta, Newbold] / - AMC13 interface - 1 month [BU, Dasgupta] / - Integration with DAQ2 / XDAQ and test - 1 month [Harder, Thea] / - Unpackers, integration with CMSSW - 1 month [Tapper, Brooke] / This sounds bad, but note that these tasks overlap 100% with the work / required for other Stage-2 boards, i.e. *every* component can be the / same for MP7, CTP7, MTF7 in principle. This would require some / agreement, however. / Note that the AMC13 interface and integration with DAQ are stalled right / now waiting on other people. / Also note that *all* these tasks are also required for Stage-1, or we / cannot read out either the MP7 or CTP7. / Dave
- 37: The duration comes from info from UW (Pams talk Trigger meeting in Feb 2014) plus one month to be safe
- 39: Hello Tiziano, Kerstin, Paris, Costas - / We had a productive 90 minute meeting on 24/4 between the US stakeholders of the Phase 1 Trigger Upgrade which focused on the details of CTP7 delivery to CERN. This is a report of the outcome - it is a long email, so set aside some time and please read to the end. In order to keep it short(er) and focused, CTP7 delivery is the only subject of this mail. / Base Delivery goal / The base delivery goal follows the current schedule in place since at least last August, but I will not discuss history further in this mail. / There are two prototypes under test, one each at Wisconsin and CERN. Parts are already in hand for 6 pre-production boards planned for delivery in July. The difference between the two prototypes and pre-production is minimal, e.g. repositioning the LEDs, and additional/spare lines for the AXI Chip2Chip bridge, so for all intents and purposes in terms of functionality they are the same. The expectation is that the production boards will be identical to the pre-production boards with the nomenclature chosen to avoid officially starting production before authorization. / Procurement activities for the production run of the board starts in May 5, which is basically right now. There are long lead times for this procurements, official state of Wisconsin procedures for sealed bid solicitation and evaluation, … and the parts have to be gathered, checked, and collated into single-board packages for assembly, such that assembled boards will be available at the UW in the first week of December. Assuming about one or two boards per week gets through the extensive testing/burnin cycle, the UW ships 4 boards every two weeks to CERN, and accounting for holidays, by Jan 31 there should be at least 8 more CTP7s at CERN, bringing the total to 12. This schedule has the balance of CTP7s delivered by March 23rd. / In order to accomplish this, the UW group is pre-funding the production run out of its own funds, to the tune of 1.67M$. There are few institutes in U.S. CMS (or I would hazard to guess in CMS as a whole) who have the ability to pre-fund at that level, and have the confidence to assume such a risk. I hope you would agree this is a clear signal of their commitment to expediting the execution of the L1 Trigger Upgrade. / Stretch Delivery Goal / We believe that the base plan delivers adequate CTP7s for the testing needs of CMS. Nevertheless, since not everyone in CMS may hold this opinion, we explored how we might be able to expedite CTP7 delivery to CERN. It is not a guarantee in any sense, and should not be incorporated into a global schedule, but it is what we will try to accomplish. / The start of the procurement stage is essentially now, so there is no possibility to start earlier. In order to compress the procurement stage, we would split it into batches, which would perhaps add a handful of more boards to the count at CERN in January but would delay the balance of the boards from March 23 to April 23, at least. We assumed that CMS would rather have all of the boards delivered earlier rather than a few more boards early at the cost of the rest a month later. So, we took compression of the procurement stage off the table. / However, it is possible that the testing/burn-in procedure can be pipelined, increasing the throughput of boards at UW. The idea is simply to process more boards in parallel, so instead of 4 boards every two weeks, you get 6. This will require increased resources at UW which we are looking into now. We could also consider shortening the actual process, at the risk of sending faulty boards to CERN and then having to bring them back to UW, so we're not particularly enthusiastic about that option. The success of the prototype boards lends confidence that the production boards will not require excessive post-production rework, which because of the expertise needed is by its nature serial. With this we will try to supply another 3-4 boards by January 31. / It is possible that the remaining boards may arrive earlier as well, although one way to expedite is to set aside rework on the "problem boards" until the end, which means in the last stage of the production testing you are left with only boards which need work, resulting in a decrease and possibly meaning the final 3-4 boards would arrive after March 23. This is a trade-off we are willing to risk. / To reiterate, base goal has 12 boards at CERN by January 31, the balance by March 23, stretch goal is to pipeline the testing to increase 12 to ~ 16. / Again, I apologize for the length of this mail but I hope it provides a clear picture of where we stand with regards to the CTP7 production. / Steve (and Wesley, Sridhara, Darin, Joel, Patty, Vivian) / ≈≈≈≈≈≈≈≈≈≈/ Steve Nahn / USCMS Phase 1 Upgrade Project Manager / nahn@fnal.gov
- 40: GAP DRIVEN BY US FUNDING PROFILE: / Dear Costas: / Main production starts on Oct. 1, 2014 / (This is funding-driven as is the case for the uHTRs). / Installation starts on Dec. 8, 2014 / These are the dates from the US CMS Schedule and designed / so that the Calorimeter Trigger is ready for connection to the HCAL / uHTRs when they are installed. / We expect to install preproduction CTP7 cards in P5 this summer. / If these dates cause a problem for a plan to have Stage 2 operating / on Jan 2016, please let me know and I will discuss / with US CMS Management. / Best regards, / Wesley 16.3.2014 / Hello Tiziano, Kerstin, Paris, Costas - / We had a productive 90 minute meeting on 24/4 between the US stakeholders of the Phase 1 Trigger Upgrade which focused on the details of CTP7 delivery to CERN. This is a report of the outcome - it is a long email, so set aside some time and please read to the end. In order to keep it short(er) and focused, CTP7 delivery is the only subject of this mail. / Base Delivery goal / The base delivery goal follows the current schedule in place since at least last August, but I will not discuss history further in this mail. / There are two prototypes under test, one each at Wisconsin and CERN. Parts are already in hand for 6 pre-production boards planned for delivery in July. The difference between the two prototypes and pre-production is minimal, e.g. repositioning the LEDs, and additional/spare lines for the AXI Chip2Chip bridge, so for all intents and purposes in terms of functionality they are the same. The expectation is that the production boards will be identical to the pre-production boards with the nomenclature chosen to avoid officially starting production before authorization. / Procurement activities for the production run of the board starts in May 5, which is basically right now. There are long lead times for this procurements, official state of Wisconsin procedures for sealed bid solicitation and evaluation, … and the parts have to be gathered, checked, and collated into single-board packages for assembly, such that assembled boards will be available at the UW in the first week of December. Assuming about one or two boards per week gets through the extensive testing/burnin cycle, the UW ships 4 boards every two weeks to CERN, and accounting for holidays, by Jan 31 there should be at least 8 more CTP7s at CERN, bringing the total to 12. This schedule has the balance of CTP7s delivered by March 23rd. / In order to accomplish this, the UW group is pre-funding the production run out of its own funds, to the tune of 1.67M$. There are few institutes in U.S. CMS (or I would hazard to guess in CMS as a whole) who have the ability to pre-fund at that level, and have the confidence to assume such a risk. I hope you would agree this is a clear signal of their commitment to expediting the execution of the L1 Trigger Upgrade. / Stretch Delivery Goal / We believe that the base plan delivers adequate CTP7s for the testing needs of CMS. Nevertheless, since not everyone in CMS may hold this opinion, we explored how we might be able to expedite CTP7 delivery to CERN. It is not a guarantee in any sense, and should not be incorporated into a global schedule, but it is what we will try to accomplish. / The start of the procurement stage is essentially now, so there is no possibility to start earlier. In order to compress the procurement stage, we would split it into batches, which would perhaps add a handful of more boards to the count at CERN in January but would delay the balance of the boards from March 23 to April 23, at least. We assumed that CMS would rather have all of the boards delivered earlier rather than a few more boards early at the cost of the rest a month later. So, we took compression of the procurement stage off the table. / However, it is possible that the testing/burn-in procedure can be pipelined, increasing the throughput of boards at UW. The idea is simply to process more boards in parallel, so instead of 4 boards every two weeks, you get 6. This will require increased resources at UW which we are looking into now. We could also consider shortening the actual process, at the risk of sending faulty boards to CERN and then having to bring them back to UW, so we're not particularly enthusiastic about that option. The success of the prototype boards lends confidence that the production boards will not require excessive post-production rework, which because of the expertise needed is by its nature serial. With this we will try to supply another 3-4 boards by January 31. / It is possible that the remaining boards may arrive earlier as well, although one way to expedite is to set aside rework on the "problem boards" until the end, which means in the last stage of the production testing you are left with only boards which need work, resulting in a decrease and possibly meaning the final 3-4 boards would arrive after March 23. This is a trade-off we are willing to risk. / To reiterate, base goal has 12 boards at CERN by January 31, the balance by March 23, stretch goal is to pipeline the testing to increase 12 to ~ 16. / Again, I apologize for the length of this mail but I hope it provides a clear picture of where we stand with regards to the CTP7 production. / Steve (and Wesley, Sridhara, Darin, Joel, Patty, Vivian) / ≈≈≈≈≈≈≈≈≈≈/ Steve Nahn / USCMS Phase 1 Upgrade Project Manager / nahn@fnal.gov
- 41: Hello Tiziano, Kerstin, Paris, Costas - / We had a productive 90 minute meeting on 24/4 between the US stakeholders of the Phase 1 Trigger Upgrade which focused on the details of CTP7 delivery to CERN. This is a report of the outcome - it is a long email, so set aside some time and please read to the end. In order to keep it short(er) and focused, CTP7 delivery is the only subject of this mail. / Base Delivery goal / The base delivery goal follows the current schedule in place since at least last August, but I will not discuss history further in this mail. / There are two prototypes under test, one each at Wisconsin and CERN. Parts are already in hand for 6 pre-production boards planned for delivery in July. The difference between the two prototypes and pre-production is minimal, e.g. repositioning the LEDs, and additional/spare lines for the AXI Chip2Chip bridge, so for all intents and purposes in terms of functionality they are the same. The expectation is that the production boards will be identical to the pre-production boards with the nomenclature chosen to avoid officially starting production before authorization. / Procurement activities for the production run of the board starts in May 5, which is basically right now. There are long lead times for this procurements, official state of Wisconsin procedures for sealed bid solicitation and evaluation, … and the parts have to be gathered, checked, and collated into single-board packages for assembly, such that assembled boards will be available at the UW in the first week of December. Assuming about one or two boards per week gets through the extensive testing/burnin cycle, the UW ships 4 boards every two weeks to CERN, and accounting for holidays, by Jan 31 there should be at least 8 more CTP7s at CERN, bringing the total to 12. This schedule has the balance of CTP7s delivered by March 23rd. / In order to accomplish this, the UW group is pre-funding the production run out of its own funds, to the tune of 1.67M$. There are few institutes in U.S. CMS (or I would hazard to guess in CMS as a whole) who have the ability to pre-fund at that level, and have the confidence to assume such a risk. I hope you would agree this is a clear signal of their commitment to expediting the execution of the L1 Trigger Upgrade. / Stretch Delivery Goal / We believe that the base plan delivers adequate CTP7s for the testing needs of CMS. Nevertheless, since not everyone in CMS may hold this opinion, we explored how we might be able to expedite CTP7 delivery to CERN. It is not a guarantee in any sense, and should not be incorporated into a global schedule, but it is what we will try to accomplish. / The start of the procurement stage is essentially now, so there is no possibility to start earlier. In order to compress the procurement stage, we would split it into batches, which would perhaps add a handful of more boards to the count at CERN in January but would delay the balance of the boards from March 23 to April 23, at least. We assumed that CMS would rather have all of the boards delivered earlier rather than a few more boards early at the cost of the rest a month later. So, we took compression of the procurement stage off the table. / However, it is possible that the testing/burn-in procedure can be pipelined, increasing the throughput of boards at UW. The idea is simply to process more boards in parallel, so instead of 4 boards every two weeks, you get 6. This will require increased resources at UW which we are looking into now. We could also consider shortening the actual process, at the risk of sending faulty boards to CERN and then having to bring them back to UW, so we're not particularly enthusiastic about that option. The success of the prototype boards lends confidence that the production boards will not require excessive post-production rework, which because of the expertise needed is by its nature serial. With this we will try to supply another 3-4 boards by January 31. / It is possible that the remaining boards may arrive earlier as well, although one way to expedite is to set aside rework on the "problem boards" until the end, which means in the last stage of the production testing you are left with only boards which need work, resulting in a decrease and possibly meaning the final 3-4 boards would arrive after March 23. This is a trade-off we are willing to risk. / To reiterate, base goal has 12 boards at CERN by January 31, the balance by March 23, stretch goal is to pipeline the testing to increase 12 to ~ 16. / Again, I apologize for the length of this mail but I hope it provides a clear picture of where we stand with regards to the CTP7 production. / Steve (and Wesley, Sridhara, Darin, Joel, Patty, Vivian) / ≈≈≈≈≈≈≈≈≈≈/ Steve Nahn / USCMS Phase 1 Upgrade Project Manager / nahn@fnal.gov
- 42: Dear Costas: / We would expect to have 3-4 preproduction CTP7s available for these tests. / Regards, / Wesley 18.3.2014 / On Mar 17, 2014, at 5:36 PM, Costas Fountas <Costas.Fountas@cern.ch> wrote: / Dear Wesley / One more thing that it is important is the following: / We should try to make the July Slice Milestone by hook and crook. / This means that you have a number of pre-production CTP7s / to participate to the slice test. / I would guess 1/3 of the total must be enough. Is this possible ? / Regards / costas
- 44: Includes the vacation for christmas and new years...so they will actualy ship later. / Consistent with the S. Nahn agreeement and the ppt agreed with Wesley....need to confirm / this on the meeting with him on the 24/10/14 at cern
- 46: Hello Tiziano, Kerstin, Paris, Costas - / We had a productive 90 minute meeting on 24/4 between the US stakeholders of the Phase 1 Trigger Upgrade which focused on the details of CTP7 delivery to CERN. This is a report of the outcome - it is a long email, so set aside some time and please read to the end. In order to keep it short(er) and focused, CTP7 delivery is the only subject of this mail. / Base Delivery goal / The base delivery goal follows the current schedule in place since at least last August, but I will not discuss history further in this mail. / There are two prototypes under test, one each at Wisconsin and CERN. Parts are already in hand for 6 pre-production boards planned for delivery in July. The difference between the two prototypes and pre-production is minimal, e.g. repositioning the LEDs, and additional/spare lines for the AXI Chip2Chip bridge, so for all intents and purposes in terms of functionality they are the same. The expectation is that the production boards will be identical to the pre-production boards with the nomenclature chosen to avoid officially starting production before authorization. / Procurement activities for the production run of the board starts in May 5, which is basically right now. There are long lead times for this procurements, official state of Wisconsin procedures for sealed bid solicitation and evaluation, … and the parts have to be gathered, checked, and collated into single-board packages for assembly, such that assembled boards will be available at the UW in the first week of December. Assuming about one or two boards per week gets through the extensive testing/burnin cycle, the UW ships 4 boards every two weeks to CERN, and accounting for holidays, by Jan 31 there should be at least 8 more CTP7s at CERN, bringing the total to 12. This schedule has the balance of CTP7s delivered by March 23rd. / In order to accomplish this, the UW group is pre-funding the production run out of its own funds, to the tune of 1.67M$. There are few institutes in U.S. CMS (or I would hazard to guess in CMS as a whole) who have the ability to pre-fund at that level, and have the confidence to assume such a risk. I hope you would agree this is a clear signal of their commitment to expediting the execution of the L1 Trigger Upgrade. / Stretch Delivery Goal / We believe that the base plan delivers adequate CTP7s for the testing needs of CMS. Nevertheless, since not everyone in CMS may hold this opinion, we explored how we might be able to expedite CTP7 delivery to CERN. It is not a guarantee in any sense, and should not be incorporated into a global schedule, but it is what we will try to accomplish. / The start of the procurement stage is essentially now, so there is no possibility to start earlier. In order to compress the procurement stage, we would split it into batches, which would perhaps add a handful of more boards to the count at CERN in January but would delay the balance of the boards from March 23 to April 23, at least. We assumed that CMS would rather have all of the boards delivered earlier rather than a few more boards early at the cost of the rest a month later. So, we took compression of the procurement stage off the table. / However, it is possible that the testing/burn-in procedure can be pipelined, increasing the throughput of boards at UW. The idea is simply to process more boards in parallel, so instead of 4 boards every two weeks, you get 6. This will require increased resources at UW which we are looking into now. We could also consider shortening the actual process, at the risk of sending faulty boards to CERN and then having to bring them back to UW, so we're not particularly enthusiastic about that option. The success of the prototype boards lends confidence that the production boards will not require excessive post-production rework, which because of the expertise needed is by its nature serial. With this we will try to supply another 3-4 boards by January 31. / It is possible that the remaining boards may arrive earlier as well, although one way to expedite is to set aside rework on the "problem boards" until the end, which means in the last stage of the production testing you are left with only boards which need work, resulting in a decrease and possibly meaning the final 3-4 boards would arrive after March 23. This is a trade-off we are willing to risk. / To reiterate, base goal has 12 boards at CERN by January 31, the balance by March 23, stretch goal is to pipeline the testing to increase 12 to ~ 16. / Again, I apologize for the length of this mail but I hope it provides a clear picture of where we stand with regards to the CTP7 production. / Steve (and Wesley, Sridhara, Darin, Joel, Patty, Vivian) / ≈≈≈≈≈≈≈≈≈≈/ Steve Nahn / USCMS Phase 1 Upgrade Project Manager / nahn@fnal.gov
- 47: Hello Tiziano, Kerstin, Paris, Costas - / We had a productive 90 minute meeting on 24/4 between the US stakeholders of the Phase 1 Trigger Upgrade which focused on the details of CTP7 delivery to CERN. This is a report of the outcome - it is a long email, so set aside some time and please read to the end. In order to keep it short(er) and focused, CTP7 delivery is the only subject of this mail. / Base Delivery goal / The base delivery goal follows the current schedule in place since at least last August, but I will not discuss history further in this mail. / There are two prototypes under test, one each at Wisconsin and CERN. Parts are already in hand for 6 pre-production boards planned for delivery in July. The difference between the two prototypes and pre-production is minimal, e.g. repositioning the LEDs, and additional/spare lines for the AXI Chip2Chip bridge, so for all intents and purposes in terms of functionality they are the same. The expectation is that the production boards will be identical to the pre-production boards with the nomenclature chosen to avoid officially starting production before authorization. / Procurement activities for the production run of the board starts in May 5, which is basically right now. There are long lead times for this procurements, official state of Wisconsin procedures for sealed bid solicitation and evaluation, … and the parts have to be gathered, checked, and collated into single-board packages for assembly, such that assembled boards will be available at the UW in the first week of December. Assuming about one or two boards per week gets through the extensive testing/burnin cycle, the UW ships 4 boards every two weeks to CERN, and accounting for holidays, by Jan 31 there should be at least 8 more CTP7s at CERN, bringing the total to 12. This schedule has the balance of CTP7s delivered by March 23rd. / In order to accomplish this, the UW group is pre-funding the production run out of its own funds, to the tune of 1.67M$. There are few institutes in U.S. CMS (or I would hazard to guess in CMS as a whole) who have the ability to pre-fund at that level, and have the confidence to assume such a risk. I hope you would agree this is a clear signal of their commitment to expediting the execution of the L1 Trigger Upgrade. / Stretch Delivery Goal / We believe that the base plan delivers adequate CTP7s for the testing needs of CMS. Nevertheless, since not everyone in CMS may hold this opinion, we explored how we might be able to expedite CTP7 delivery to CERN. It is not a guarantee in any sense, and should not be incorporated into a global schedule, but it is what we will try to accomplish. / The start of the procurement stage is essentially now, so there is no possibility to start earlier. In order to compress the procurement stage, we would split it into batches, which would perhaps add a handful of more boards to the count at CERN in January but would delay the balance of the boards from March 23 to April 23, at least. We assumed that CMS would rather have all of the boards delivered earlier rather than a few more boards early at the cost of the rest a month later. So, we took compression of the procurement stage off the table. / However, it is possible that the testing/burn-in procedure can be pipelined, increasing the throughput of boards at UW. The idea is simply to process more boards in parallel, so instead of 4 boards every two weeks, you get 6. This will require increased resources at UW which we are looking into now. We could also consider shortening the actual process, at the risk of sending faulty boards to CERN and then having to bring them back to UW, so we're not particularly enthusiastic about that option. The success of the prototype boards lends confidence that the production boards will not require excessive post-production rework, which because of the expertise needed is by its nature serial. With this we will try to supply another 3-4 boards by January 31. / It is possible that the remaining boards may arrive earlier as well, although one way to expedite is to set aside rework on the "problem boards" until the end, which means in the last stage of the production testing you are left with only boards which need work, resulting in a decrease and possibly meaning the final 3-4 boards would arrive after March 23. This is a trade-off we are willing to risk. / To reiterate, base goal has 12 boards at CERN by January 31, the balance by March 23, stretch goal is to pipeline the testing to increase 12 to ~ 16. / Again, I apologize for the length of this mail but I hope it provides a clear picture of where we stand with regards to the CTP7 production. / Steve (and Wesley, Sridhara, Darin, Joel, Patty, Vivian) / ≈≈≈≈≈≈≈≈≈≈/ Steve Nahn / USCMS Phase 1 Upgrade Project Manager / nahn@fnal.gov
- 48: The assumption here is that no surpirses and no disasters occur which require significant redesign....if this happens all bets are off.....
- 58: Dear Costas, / I think July 14 slice test is a good goal. We have the CTP7 / for it and people allocated to do the layer-1 firmware. It / looks feasible from my point of view. / Regards, / Sridhara 2.4.2014
- 64: Tim Durkin estimates 12 weeks for manufacture
- 65: Tim Durkin estimates 4 weeks for precabling at RAL

| ID | WBS | Task | Type | Duration | Start | Finish | Predecessors | Total slack | Free slack | Constraint | Resources | Work |
| --- | --- | --- | --- | --- | --- | --- | --- | --- | --- | --- | --- | --- |
| 71 | 1.70 | oSLB/uHTR to Layer -1 Patch Panel installation + Fibers |  | 2w | 2014-10-28 | 2014-11-10 | 59, 70, 43 | 185d | 0d |  | Da Silva; E. Laird | 160h |
| 72 | 1.71 | Layer-1 Crate installation (3 uTCA crates for CTP7) + TCDS + AMC13 |  | 2w | 2014-10-28 | 2014-11-10 | 67, 59, 43 | 185d | 0d |  | Svetek | 80h |
| 73 | 1.72 | Interconnection testing of Layer-2, Layer-1/Layer-2 Patch Panel,l and 1/9 Layer-1 |  | 2w | 2014-11-11 | 2014-11-24 | 63, 59, 9, 72, 43, 71 | 204d | 0d |  | A Bundock; T. Durkin; Svetek | 240h |
| 74 | 1.73 | Commissioning DeMux + Layer-2 + Patch Panel + (1/9)Layer-1 |  | 4w | 2014-11-25 | 2014-12-20 | 73 | 204d | 0d |  | Svetek [50%]; A Bundock; T. Durkin | 400h |
| 75 | 1.74 | Layer-2 + Patch Panel + 1/9 of Layer-1 Commissioned | milestone | 1d? | 2014-12-22 | 2014-12-22 | 74 | 204d | 9d |  |  |  |
| 76 | 1.75 | Commissioning of 2016 Trigger Part - 0 (V1 Firmware 12 MP7s+4 CTP7s) Patterns |  | 4w | 2014-11-26 | 2014-12-22 | 60, 73 | 204d | 9d |  | A Bundock; A Rose; Svetek [50%] | 400h |
| 77 | 1.76 | Integration of the 2016 Trigger DemMux at P5 with uGT |  | 4w | 2014-09-01 | 2014-09-26 | 58, 18 | 266d | 71d | start no earlier than 2014-09-01 | Dasgupta; Tapper; Brooke; K. Harder; Newbold | 800h |
| 78 | 1.77 | CERN CLOSED FOR CHRISTMAS AND NEW YEAR |  | 11d? | 2014-12-20 | 2015-01-04 |  | 195d | 0d | finish no earlier than 2015-01-04 |  |  |
| 79 | 1.78 | Connecting Layer-1/PP/Layer-2/Demux to uGT |  | 2w | 2015-01-05 | 2015-01-16 | 75, 77, 78, 76 | 195d | 0d |  |  |  |
| 80 | 1.79 | Layer-2 + Patch Panel + 1/9 of Layer-1 Connected to uGT | milestone | 1d? | 2015-01-19 | 2015-01-19 | 79 | 195d |  |  |  |  |
| 81 | 1.80 | Commissioning of the oSLB links to the 4 CTP7s at P5 |  | 10w | 2014-11-11 | 2015-01-16 | 71, 72 | 155d | 22d |  | Da Silva; Marcelo [50%] | 600h |
| 82 | 1.81 | Commissioning the 36 HF uHTR fibers to 4 Layer-1 CTP7s |  | 10w | 2014-11-11 | 2015-01-16 | 72 | 185d | 22d |  | Marcelo [50%]; E. Laird | 600h |
| 83 | 1.82 | HF 36 uHTR and oSLB System Commissioned | milestone | 0d | 2015-01-16 | 2015-01-16 | 82 | 196d |  |  |  |  |
| 84 | 1.83 | Commisioning - 12 MP7+ 8 CTP7 2016 trigger Patterns |  | 1mo | 2015-01-21 | 2015-02-17 | 61, 62, 25, 45 | 88d | 0d |  | A Rose; A Bundock; Svetek | 480h |
| 85 | 1.84 | System Test test oSLB+HF uHTR-->8xCTP7-->12xMP7-->Demux-->uGT |  | 1mo | 2015-02-18 | 2015-03-17 | 84, 81, 82 | 133d | 0d |  |  |  |
| 86 | 1.85 | Layer-1 CTP7 DAQ Link Development work - Common with Stage-1 (Easter incl.) |  | 1mo | 2015-03-18 | 2015-04-14 | 85 | 113d | 0d |  | Svetek; K. Harder; D Newbold; Dasgupta | 640h |
| 87 | 1.86 | Layer-1 + Layer-2 DAQ Interface test with DAQ |  | 4w | 2015-04-15 | 2015-05-12 | 86 | 113d | 0d |  | D Newbold; Dasgupta; K. Harder; Svetek | 640h |
| 88 | 1.87 | 2016 Trigger with HF+oSLB Ready | milestone | 1d? | 2015-05-13 | 2015-05-13 | 87 | 113d |  |  |  |  |
| 89 | 1.88 | Commissioning HCAL B/E uHTR system with trigger 12/36 Layer-1 |  | 5w | 2015-02-18 | 2015-03-24 | 48, 84 | 88d | 0d |  |  |  |
| 90 | 1.89 | Commissioning of the HCAL B/E uHTR system with trigger 28/36 Layer-1 |  | 1mo | 2015-03-25 | 2015-04-21 | 53, 89 | 88d | 0d |  |  |  |
| 91 | 1.90 | Commissioning of the HCAL BE/uHTR systerm with trigger 36/36 Layer-1 |  | 2mo | 2015-04-22 | 2015-06-16 | 90, 56 | 88d | 34d |  |  |  |
| 92 | 1.91 | Barrel and EndCap uHTR systems connected to the Layer-1 CTP7s - Trigger Inputs Commisioned | milestone | 1d? | 2015-06-17 | 2015-06-17 | 91 | 88d |  |  |  |  |
| 93 | 1.92 | Online Monitoring Software for the 2016 Trigger |  | 10mo | 2014-10-01 | 2015-07-06 |  | 74d | 41d | start no earlier than 2014-10-01 |  |  |
| 94 | 1.93 | 2016 Trigger final Emulators |  | 5mo | 2014-10-01 | 2015-02-16 | 26, 27, 28, 36 | 53d | 0d | start no earlier than 2014-10-01 |  |  |
| 95 | 1.94 | Final design of Algorithms and Data Format defined | milestone | 1d? | 2015-02-17 | 2015-02-17 | 94 | 53d | 0d |  |  |  |
| 96 | 1.95 | Final Firmware for the 2016 Trigger + Validation + Upgrades |  | 7mo | 2015-02-18 | 2015-09-01 | 36, 95 | 33d | 0d | start no earlier than 2014-10-01 |  |  |
| 97 | 1.96 | 2016 Trigger Ready for Parallel Data Taking | milestone | 1d? | 2015-09-02 | 2015-09-02 | 89, 93, 96, 91 | 33d |  |  |  |  |
| 98 | 1.97 | ORSc Firmware - V1 for the APRIL2014 RCT->ORSc->MP7 test |  | 83d | 2014-01-01 | 2014-04-25 |  | 52d | 0d | start no earlier than 2014-01-01 | Svetek [10%]; Matias [80%] | 597.6h |
| 99 | 1.98 | ORSc Testing software for the April-2014 RCT->ORSc->MP7 test |  | 83d | 2014-01-01 | 2014-04-25 |  | 52d | 0d | start no earlier than 2014-01-01 | Klabbers; Cali | 1328h |
| 100 | 1.99 | RCT-ORSc-MP7 -- Integration Tests at 904 - 10 GBps Links |  | 3w | 2014-04-28 | 2014-05-16 | 98, 99 | 52d | 0d |  | Svetek [50%]; Cali [50%]; Klabbers [50%]; Iles [50%] | 240h |
| 101 | 1.100 | ORSCs Integrated with RCT and MP7 and ready for production | milestone | 1d? | 2014-05-19 | 2014-05-19 | 100 | 52d | 0d |  |  |  |
| 102 | 1.101 | ORSc Firmware for Integration with Legacy GCT |  | 1mo | 2014-05-20 | 2014-06-16 | 101 | 58d | 0d |  | Iles [20%]; Marcelo | 192h |
| 103 | 1.102 | OSCs integration tests with Legacy GCT - 2GBps links |  | 1mo | 2014-06-17 | 2014-07-14 | 102 | 58d | 0d |  | Iles [20%]; Marcelo | 192h |
| 104 | 1.103 | ORSCs Integrated with Legacy GCT | milestone | 1d? | 2014-07-15 | 2014-07-15 | 103 | 58d | 0d |  |  |  |
| 105 | 1.104 | 1st Global Run April 7.4 - 11.4 |  | 5d? | 2014-04-07 | 2014-04-11 |  | 397d |  | start no earlier than 2014-04-07 |  |  |
| 106 | 1.105 | ORSc Production |  | 1mo | 2014-05-20 | 2014-06-16 | 101 | 52d | 0d |  | Gorski [50%] | 80h |
| 107 | 1.106 | ORSc Testing at Madison |  | 1mo | 2014-06-17 | 2014-07-14 | 106 | 52d | 0d |  | Gorski | 160h |
| 108 | 1.107 | Easter Week 18.4 - 21.4 |  | 2d? | 2014-04-18 | 2014-04-21 |  | 391d |  | start no earlier than 2014-04-18 |  |  |
| 109 | 1.108 | Power off at P5 |  | 16d? | 2014-04-29 | 2014-05-20 |  | 370d |  | start no earlier than 2014-04-29 |  |  |
| 110 | 1.109 | Commissioning Software testing interconnectivity at P5 |  | 1mo | 2014-04-28 | 2014-05-23 | 99 | 114d | 62d |  | GM Innocenti | 160h |
| 111 | 1.110 | Installation of uTCA Crate at P5 with MP7 |  | 2w | 2014-05-20 | 2014-06-02 | 101 | 88d | 36d |  | Iles | 80h |
| 112 | 1.111 | ORSCs Testing complete | milestone | 1d? | 2014-07-15 | 2014-07-15 | 107 | 52d | 0d |  |  |  |
| 113 | 1.112 | ORSc transport US-->CERN |  | 1w | 2014-07-16 | 2014-07-22 | 112 | 52d | 0d |  |  |  |
| 114 | 1.113 | ORSC Installation at P5 including all fibers to GCT+MP7 + Patch Panel |  | 1mo | 2014-07-23 | 2014-08-19 | 113, 111 | 52d | 0d |  | Cali; Klabbers | 320h |
| 115 | 1.114 | Comissioning ECAL/HCAL/ORSC/MP7 system interconnectivity at P5 with ORSC gen. Patterns |  | 20d | 2014-08-20 | 2014-09-16 | 114, 110, 104 | 52d | 0d |  | Cali | 160h |
| 116 | 1.115 | ORSCs Installation and testing with MP7 at P5 Complete | milestone | 1d? | 2014-09-17 | 2014-09-17 | 115 | 52d | 0d |  |  |  |
| 117 | 1.116 | ORSc firmware for running Stage-1 |  | 2mo | 2014-05-20 | 2014-07-14 | 101 | 59d | 1d |  | Guo | 320h |
| 118 | 1.117 | ORSC Firmware for running the Legacy trigger |  | 2mo | 2014-07-16 | 2014-09-09 | 117, 104 | 58d | 6d |  | Marcelo | 320h |
| 119 | 1.118 | 2nd Global Run 3.7 - 10.7.2014 |  | 6d? | 2014-07-03 | 2014-07-10 |  | 333d |  | start no earlier than 2014-07-03 |  |  |
| 120 | 1.119 | Comm the Legacy Running via ORSC 2GBps - Move 108 ECL - No Trigger |  | 1mo | 2014-09-18 | 2014-10-15 | 118, 116 | 52d | 0d |  | Iles [25%]; Thea; Marcelo | 360h |
| 121 | 1.120 | Legacy System Can Trigger with ORSc input | milestone | 1d? | 2014-10-16 | 2014-10-16 | 120 | 52d | 0d |  |  |  |
| 122 | 1.121 | Comissioning of the Stage-1 running firmware and integration with GT |  | 1mo | 2014-10-17 | 2014-11-13 | 116, 121 | 52d | 0d |  | Guo; Cali; Klabbers; Iles [50%] | 480h |
| 123 | 1.122 | Stage-1 Comm. In Parallel with Legacy | milestone | 1d? | 2014-11-14 | 2014-11-14 | 122 | 52d | 0d |  |  |  |
| 124 | 1.123 | Stage-1 MP7 DAQ link devel. and integration - Common with Stage-1 |  | 1mo | 2014-11-17 | 2014-12-12 | 123 | 216d | 0d |  | D Newbold; Dasgupta | 320h |
| 125 | 1.124 | Commissioning of the Stage-1 MP7 DAQ LINK |  | 1w | 2014-12-15 | 2014-12-19 | 124 | 216d | 0d |  |  |  |
| 126 | 1.125 | Stage-1 MP7 DAQ Link Commissioned | milestone | 1d? | 2014-12-20 | 2014-12-20 | 125 | 216d |  |  |  |  |
| 127 | 1.126 | ORSc firmware for testing+Validation+Monitoring the Legacy system+Comm |  | 2mo | 2014-11-17 | 2015-01-08 | 123 | 202d |  |  | Marcelo | 320h |
| 128 | 1.127 | ORSc Software for testing+Validation+Monitoring the Legacy System+Comm |  | 2mo | 2014-11-17 | 2015-01-08 | 123 | 201d | 0d |  | Thea [50%]; M Guilbaud | 480h |
| 129 | 1.128 | Legacy System Fully Integrated with ORSc | milestone | 1d? | 2015-01-09 | 2015-01-09 | 128, 118 | 201d |  |  |  |  |
| 130 | 1.129 | Electron and Tau Algorithm Firmware development for MP7 |  | 6mo | 2014-04-01 | 2014-09-15 |  | 165d | 2d | start no earlier than 2014-04-01 | Firmware Enginner 1 | 960h |
| 131 | 1.130 | Electron and Tau Algorithm Pre comissioning at 904 |  | 2mo | 2014-09-18 | 2014-11-12 | 130, 116 | 163d | 0d |  | Firmware Enginner 1 | 320h |
| 132 | 1.131 | Electron and Tau Algorithm Commisioning at P5 |  | 1mo | 2014-11-13 | 2014-12-10 | 131 | 163d | 0d |  |  |  |
| 133 | 1.132 | Electron and Tau Trigger Validation vs Emulator |  | 3mo | 2014-12-11 | 2015-03-03 | 132 | 163d | 2d |  | Firmware Enginner 1; Cali | 960h |
| 134 | 1.133 | Monitoring Software for Stage -1 Electron and Tau Triggers |  | 4mo | 2014-11-17 | 2015-03-05 | 123 | 161d | 0d |  | GM Innocenti | 640h |
| 135 | 1.134 | Electron/Tau Triggers Ready and Validated | milestone | 1d? | 2015-03-06 | 2015-03-06 | 134, 133 | 161d |  |  |  |  |
| 136 | 1.135 | Jet+MET+MHT Algorithm Firmware Development |  | 6mo | 2014-04-01 | 2014-09-15 |  | 36d | 0d | start no earlier than 2014-04-01 | Firmware Engineer 2 | 960h |
| 137 | 1.136 | JET+MET+MHT Algorithm precommissining |  | 3mo | 2014-09-16 | 2014-12-08 | 136 | 36d | 0d |  | Firmware Engineer 2 | 480h |
| 138 | 1.137 | JET+MET+MHT Firmware Commissioning at P5 |  | 1mo | 2014-12-09 | 2015-01-02 | 123, 137 | 36d | 0d |  | Firmware Engineer 2 | 160h |
| 139 | 1.138 | JET+MET+MHT Trigger Validation vs Emulator |  | 3mo | 2015-01-05 | 2015-03-27 | 138 | 36d | 0d |  | Firmware Engineer 2; M Guilbaud | 960h |
| 140 | 1.139 | Monitoring Software for Stage -1 JET/MET/MHT (Hardonic Triggers) |  | 4mo | 2014-11-17 | 2015-03-05 | 123 | 52d | 16d |  |  |  |

Notes:
- 73: Thre are 12 MP7 in Layer 2 and each has as inputs 2 ribons of 36 fibers each. So we have in total 24 Ribons and 24x36=864 fibers coming in to Layer-2 at 10 GBps / There are 36 CTP7 each with 2 ribbons of 12 fibers. So we have 36x2 = 72 ribons. In other words there are 72x12 = 864 fibers coming out of Layer-1
- 100: 2 weeks may not be enough considering that that needed 1 week just to agree on the protocol and yet not have an agreement.....
- 115: At this point we disconnet the 108 cables from the lagacy and connect the to ORSCs. / The ORSCs feed both the Legacy GCT as well as the MP7/Stage-1 crate

| ID | WBS | Task | Type | Duration | Start | Finish | Predecessors | Total slack | Free slack | Constraint | Resources | Work |
| --- | --- | --- | --- | --- | --- | --- | --- | --- | --- | --- | --- | --- |
| 141 | 1.140 | STAGE-1 MET/MHT/JETS AND ALL OTHER TRIGGERS DONE | milestone | 0d | 2015-03-27 | 2015-03-27 | 139, 140 | 36d |  |  |  |  |
| 142 | 1.141 | Heavy Ion Emulator Development |  | 56d | 2014-09-15 | 2014-12-01 |  | 0d |  | start no earlier than 2014-09-15 | Cali; A. Barbieri; M. Northrup | 1344h |
| 143 | 1.142 | First Version of Heavy Ion Emulators finished | milestone | 1d? | 2014-12-02 | 2014-12-02 | 142 | 0d |  |  |  |  |
| 144 | 1.143 | Preparing e/gamma VHDL and gaining exeprince with the HI MP7 |  | 2mo | 2014-11-03 | 2014-12-25 |  | 32d | 0d | start no earlier than 2014-11-03 | Cali; D Newbold [25%] | 400h |
| 145 | 1.144 | Validate with patterns and MC the E/gammar Algorithm Firmware |  | 1mo | 2014-12-26 | 2015-01-22 | 144 | 32d | 0d |  | Cali | 160h |
| 146 | 1.145 | Electron/Photon Trigger Validated on the bench | milestone | 0d | 2015-01-22 | 2015-01-22 | 145 | 32d | 0d |  |  |  |
| 147 | 1.146 | Instalation of HI PatchPanel, Links and MP7 at P5 |  | 2w | 2015-05-19 | 2015-06-01 | 141, 158 | 0d |  |  | Marcelo | 80h |
| 148 | 1.147 | Test the HI DAQ and TCDS connections |  | 1mo | 2015-06-02 | 2015-06-29 | 147 | 0d |  |  | Marcelo | 160h |
| 149 | 1.148 | Running the HI Algorithms parasiticaly and validating with pp data |  | 4mo | 2015-06-30 | 2015-10-19 | 148 | 0d |  |  |  |  |
| 150 | 1.149 | Jet Algorithm + PU VHDL Firmware Development for HI |  | 2mo | 2014-12-03 | 2015-01-26 | 143 | 0d |  |  | Marcelo | 320h |
| 151 | 1.150 | Validate with patterns the Jets and PU algorithm |  | 2mo | 2015-01-27 | 2015-03-23 | 150 | 0d |  |  | Marcelo | 320h |
| 152 | 1.151 | Jet and PU alogorithm Validated on the Bench | milestone | 0d | 2015-03-23 | 2015-03-23 | 151 | 0d |  |  |  |  |
| 153 | 1.152 | Centrality Algorithm VHDL Development |  | 2mo | 2015-01-23 | 2015-03-19 | 146 | 32d | 0d |  | Cali | 320h |
| 154 | 1.153 | Validation of the Centrality Algorithm Firmware |  | 2mo | 2015-03-20 | 2015-05-14 | 153 | 32d | 0d |  | Cali | 320h |
| 155 | 1.154 | Centrality Algorithm Validates on the Bench | milestone | 0d | 2015-05-14 | 2015-05-14 | 154 | 32d | 0d |  |  |  |
| 156 | 1.155 | 4x4 Et algorithm (Track) VHDL development and Validation |  | 1mo | 2015-03-24 | 2015-04-20 | 152 | 0d |  |  | Marcelo | 160h |
| 157 | 1.156 | 4x4 Et (Track) algorithm Validation on the bench |  | 1mo | 2015-04-21 | 2015-05-18 | 156 | 0d |  |  | Marcelo | 160h |
| 158 | 1.157 | Track Trigger Validated on the Bench | milestone | 0d | 2015-05-18 | 2015-05-18 | 157 | 0d |  |  |  |  |
| 159 | 1.158 | Event Shape Algorithm Firmware |  | 2mo | 2015-05-15 | 2015-07-09 | 155 | 32d | 0d |  | Cali | 320h |
| 160 | 1.159 | Event Shape Algorihmt tests on the bench |  | 2mo | 2015-07-10 | 2015-09-03 | 159 | 32d | 0d |  | Cali | 320h |
| 161 | 1.160 | Event Shape Algorithm Validated on the bench | milestone | 0d | 2015-09-03 | 2015-09-03 | 160 | 32d |  |  |  |  |
| 162 | 1.161 | oSLB - 650 - JTAG testing |  | 1mo | 2014-01-06 | 2014-01-31 |  | 370d | 0d | start no earlier than 2014-01-06 | Anatoli | 160h |
| 163 | 1.162 | oLSB - 650 - Programming - functionality testing - Links |  | 1mo | 2014-02-03 | 2014-02-28 | 162 | 370d | 0d |  | Marcelo; Da Silva [25%] | 200h |
| 164 | 1.163 | oLSB testing finished | milestone | 1d? | 2014-03-03 | 2014-03-03 | 163 | 426d |  |  |  |  |
| 165 | 1.164 | oRM - 650 - JTAG testing and Link testing |  | 1mo | 2014-02-12 | 2014-03-11 |  | 343d | 0d | start no earlier than 2014-02-12 | Anatoli | 160h |
| 166 | 1.165 | oRM - 650 - functionality testing - Links |  | 1mo | 2014-03-12 | 2014-04-08 | 165 | 343d | 0d |  | Marcelo [50%]; Klabbers [75%]; Anatoli [75%] | 320h |
| 167 | 1.166 | oRM Testing Finished | milestone | 1d? | 2014-04-09 | 2014-04-09 | 166 | 399d |  |  |  |  |
| 168 | 1.167 | oSLB TCC oRM/CTP7 + uHTR/CTP7 oRM Integration tests at 904 24.2 - 21.3 |  | 1mo | 2014-02-24 | 2014-03-21 |  | 345d | 0d | start no earlier than 2014-02-24 | Yannick; Da Silva [25%]; Marcelo [50%] | 226.67h |
| 169 | 1.168 | Last TCC/oSLB/oRM/RC/HTR-HCAL integration test at P5 24.3 - 4.4 |  | 2w | 2014-03-24 | 2014-04-04 | 168 | 345d | 2d |  | Klabbers [75%]; Da Silva [75%]; Yannick; Zabi | 280h |
| 170 | 1.169 | oLSB/oRM system ready for Installation - Final Go ahead | milestone | 1d? | 2014-04-09 | 2014-04-09 | 169, 166, 163 | 343d | 2d |  |  |  |
| 171 | 1.170 | 1ST GLOBAL RUN 7.4 - 11.4 - Legacy Trigger + 1 oSLB crate |  | 1w | 2014-04-07 | 2014-04-11 |  | 341d | 0d | start no earlier than 2014-04-07 |  |  |
| 172 | 1.171 | Removing ECAL Trigger Cables - Fiber Installation 1st week |  | 1w | 2014-04-14 | 2014-04-18 | 171, 170 | 341d | 1d |  | Zabi; LLR-Tech-1; LLR-Tech-2 | 120h |
| 173 | 1.172 | Easter Vacation Cern Closed 18.4 - 21.4 |  | 2d? | 2014-04-18 | 2014-04-21 |  | 340d | 0d | start no earlier than 2014-04-18 |  |  |
| 174 | 1.173 | Power off at P5 29.4 - 20.5 |  | 16d? | 2014-04-29 | 2014-05-20 |  | 370d |  | start no earlier than 2014-04-29 |  |  |
| 175 | 1.174 | Removing ECAL Trigger Cables - Fiber Installation 2d week |  | 1w | 2014-04-22 | 2014-04-28 | 171, 170, 173, 172 | 340d | 0d |  | Zabi; LLR-Tech-1; LLR-Tech-2 | 120h |
| 176 | 1.175 | Fiber Installation etc that require no rack power |  | 3w | 2014-04-29 | 2014-05-19 | 175 | 340d | 0d |  | LLR-Tech-1; Zabi; LLR-Tech-2 | 360h |
| 177 | 1.176 | oSLB - oRM installation and Commissioning Crate-by-Crate |  | 30d | 2014-05-20 | 2014-06-30 | 176 | 340d | 0d |  | Da Silva; Klabbers; Thierry; Zabi; Yannick | 1200h |
| 178 | 1.177 | oSLB-oRM Interface Ready for the Second CMS Global Run | milestone | 1d? | 2014-07-01 | 2014-07-01 | 177 | 340d |  |  |  |  |
| 179 | 1.178 | 2ND GLOBAL RUN 3.7 - 10.7 2014 - With Legacy RCT/GCT + oRM/oSLB |  | 6d? | 2014-07-03 | 2014-07-10 |  | 333d |  | start no earlier than 2014-07-03 |  |  |

Notes:
- 142: 10/9/2014 - Meeting with Bolek, Ivan, Darin and Costas / There are two PU Subtraction Algorithms / (a) PUM0 - Comes from PP and cunts / the numer of empty 4x4 tower regions and / correlated this to PU which then subtracts / (b) Phi-ring method. Prefers BY Heavy Ion People / Finds <Et> per Phi-Ring and then subtracts / Important for Jets in HI - We need to study the preformance / of Jet algorithms for HI with both PUM0 and Phi-ring / The HI Triggers are: / 4x4 Et Trigger called Track Trigger / e/gama / Jets / Event Shape / Centrality / The most important of them are the Jets and the / Centrality. The Centrality does not need PU subtraction / and it is finished. Jets and PU subtraction are key now. / Need to study the prerfomrance of all these in details
- 144: Strip MP7 Firmware from pp algorithms and keep / just the E/gamma which is the same.
- 162: ·576 oSLBs (324 EB + 252 EE) with two output links; one for legacy one for upgrade
- 163: Hi Costas / You are assuming that it took a week to program 60…this is wrong… / We have stopped programming after the Slot#1 issue,… / we need 45min to program 18 oSLB and validate/check the configuration and 10 min link tests … so to program and test 620 we need one week! / Regards / JC / According to this we need about 650/18 = 36 hours which is a week. I will put down a month to be safe
- 166: ·565 (540 +25 HF) oRMs to receive the data on the RCT side
